# Buildd Generalisation

Schedule from Planner, 2009-11-09 to 2009-12-02.
Canonical

## Calendars

- Default: Mon-Fri 09:00-13:00, 14:00-18:00; Sat-Sun off.

## Resources

| Resource |
| --- |
| mwhudson |
| jtv |
| bigjools |
| noodles |
| al-maisan |

## Schedule

| ID | WBS | Task | Type | Duration | Start | Finish | Predecessors | Constraint | Resources | Work |
| --- | --- | --- | --- | --- | --- | --- | --- | --- | --- | --- |
| 1 | 1 | **Milestone 3.1.11** |  | 17d | 2009-11-09 | 2009-12-01 |  | must start on 2009-12-02 |  | 624h |
| 2 | 1.1 | LAZR-JS |  | 5d | 2009-11-09 | 2009-11-13 |  | must start on 2009-11-09 | jtv [50%]; noodles [50%] | 40h |
| 3 | 1.2 | Bazaar sprint |  | 5d | 2009-11-09 | 2009-11-13 |  | must start on 2009-11-09 | mwhudson | 40h |
| 4 | 1.3 | UDS |  | 5d | 2009-11-16 | 2009-11-20 |  | must start on 2009-11-16 | bigjools [50%]; al-maisan [50%] | 40h |
| 5 | 1.4 | UDS-noodles |  | 3d | 2009-11-16 | 2009-11-18 |  | must start on 2009-11-16 | noodles | 24h |
| 6 | 1.5 | **Write schema patch** |  |  | 2009-11-09 | 2009-11-16 |  |  |  | 48h |
| 7 | 1.5.1 | Soyuz-specific refactoring for BuildQueue and BuildJobPackage |  |  | 2009-11-09 | 2009-11-10 |  |  | bigjools; al-maisan | 32h |
| 8 | 1.5.2 | Add BuildTranslationJob |  |  | 2009-11-16 | 2009-11-16 | 2 |  | jtv | 8h |
| 9 | 1.5.3 | Add BuildPackageBranchJob |  |  | 2009-11-16 | 2009-11-16 | 3 |  | mwhudson | 4h |
| 10 | 1.5.4 | Add BuildPackageRecipeJob |  |  | 2009-11-16 | 2009-11-16 | 9 |  | mwhudson | 4h |
| 11 | 1.5.5 | Land schema patch | milestone | 0d | 2009-11-16 | 2009-11-16 | 10, 8, 7 |  |  |  |
| 12 | 1.6 | **Refactor IBuilder** |  |  | 2009-11-19 | 2009-11-23 | 5 |  |  | 24h |
| 13 | 1.6.1 | Create IBuilderPackage and populate with soyuz specifics |  |  | 2009-11-19 | 2009-11-20 |  |  | noodles | 16h |
| 14 | 1.6.2 | Fix myriad tests |  |  | 2009-11-23 | 2009-11-23 | 13 |  | noodles | 8h |
| 15 | 1.7 | **Create new builder type non-model classes** |  |  | 2009-11-24 | 2009-11-27 | 12 |  |  | 64h |
| 16 | 1.7.1 | Create IBuilderTranslations |  |  | 2009-11-24 | 2009-11-25 |  |  | jtv | 16h |
| 17 | 1.7.2 | Create IBuilderPackageBranch |  |  | 2009-11-24 | 2009-11-25 |  |  | mwhudson | 16h |
| 18 | 1.7.3 | Create IBuilderPackageRecipe |  |  | 2009-11-26 | 2009-11-27 | 17 |  | mwhudson | 16h |
| 19 | 1.7.4 | Figure out how IBuilder.findBuildCandidate() should now work |  |  | 2009-11-24 | 2009-11-25 |  |  | noodles | 16h |
| 20 | 1.8 | **Create new Build model classes** |  |  | 2009-11-17 | 2009-11-20 | 11 |  |  | 48h |
| 21 | 1.8.1 | Create IBuildPackageBranchJob |  |  | 2009-11-17 | 2009-11-18 |  |  | mwhudson | 16h |
| 22 | 1.8.2 | Create IBuildPackageRecipeJob |  |  | 2009-11-19 | 2009-11-20 | 21 |  | mwhudson | 16h |
| 23 | 1.8.3 | Create IBuildTranslationsJob |  |  | 2009-11-17 | 2009-11-18 |  |  | jtv | 16h |
| 24 | 1.9 | **manager -> slave protocol** |  |  | 2009-11-09 | 2009-11-17 |  |  |  | 96h |
| 25 | 1.9.1 | Design new protocol(s) for generic jobs |  |  | 2009-11-09 | 2009-11-10 |  |  |  | 16h |
| 26 | 1.9.2 | Update buildd/slave.py |  |  | 2009-11-11 | 2009-11-17 | 25 |  |  | 40h |
| 27 | 1.9.3 | Update buildd-manager |  |  | 2009-11-11 | 2009-11-17 | 25 |  |  | 40h |

| ID | WBS | Task | Type | Duration | Start | Finish | Predecessors | Constraint | Work |
| --- | --- | --- | --- | --- | --- | --- | --- | --- | --- |
| 28 | 1.10 | **Fix broken build ETAs** |  |  | 2009-11-18 | 2009-11-23 | 24 |  | 32h |
| 29 | 1.10.1 | Figure out what to do, exactly |  |  | 2009-11-18 | 2009-11-18 |  |  | 8h |
| 30 | 1.10.2 | Refactor code from IBuild |  |  | 2009-11-19 | 2009-11-23 | 29 |  | 24h |
| 31 | 1.11 | **Deal with results of jobs** |  |  | 2009-11-23 | 2009-11-27 | 20, 24 |  | 120h |
| 32 | 1.11.1 | Package branch builds |  |  | 2009-11-23 | 2009-11-27 |  |  | 40h |
| 33 | 1.11.2 | Package recipe builds |  |  | 2009-11-23 | 2009-11-27 |  |  | 40h |
| 34 | 1.11.3 | Translations builds |  |  | 2009-11-23 | 2009-11-27 |  |  | 40h |
| 35 | 1.12 | **Package upload decoupling** |  |  | 2009-11-09 | 2009-11-11 |  |  | 48h |
| 36 | 1.12.1 | move storeBuildInfo() to IBuild |  |  | 2009-11-09 | 2009-11-11 |  |  | 24h |
| 37 | 1.12.2 | p-u to deal with binary upload failures |  |  | 2009-11-09 | 2009-11-11 |  |  | 24h |
| 38 | 1.13 | 3.1.11 Release | milestone | 0d | 2009-12-02 | 2009-12-02 |  | must start on 2009-12-02 |  |
